# BB-10 - metselwerk+kolommen

Schedule from MS Project, 2003-01-12 to 2003-02-03, status date 2003-01-08.
BAM Nelissen Van Egteren

## Calendars

- ALLEEN WERKDAGEN: Mon-Fri 08:30-12:30, 13:00-17:00; Sat-Sun off. Exceptions (off unless hours are given): 2003-01-11 to 2003-01-12 08:30-12:30, 13:00-17:00, 2003-01-18 to 2003-01-19 08:30-12:30, 13:00-17:00, 2003-01-25 to 2003-01-26 08:30-12:30, 13:00-17:00, 2003-02-01 to 2003-02-02 08:30-12:30, 13:00-17:00.

## Schedule

| ID | WBS | Task | Type | Duration | Start | Finish | Predecessors | Total slack |
| --- | --- | --- | --- | --- | --- | --- | --- | --- |
| 1 | 1 | **BOVENBOUWFASE** |  | 23d | 2003-01-12 | 2003-02-03 |  | 0d |
| 2 | 1.1 | stalen/beton kolommen stellen |  | 4d | 2003-01-12 | 2003-01-15 |  | 0d |
| 3 | 1.2 | kozijnen+profielen stellen |  | 4d | 2003-01-15 | 2003-01-18 | 2SS+3d | 0d |
| 4 | 1.3 | wanden metselen vanaf beg.grond |  | 7d | 2003-01-19 | 2003-01-25 | 3SS+4d | 0d |
| 5 | 1.4 | metselsteiger opbouwen |  | 2d | 2003-01-25 | 2003-01-26 | 4SS+6d | 0d |
| 6 | 1.5 | wanden metselen tot dak |  | 7d | 2003-01-26 | 2003-02-01 | 5SS+1d | 0d |
| 7 | 1.6 | dakbalklaag leggen |  | 4d | 2003-01-31 | 2003-02-03 | 6SS+5d | 0d |
| 8 | 1.7 | start gevel/dak fase | milestone | 0d | 2003-02-03 | 2003-02-03 | 7SS+4d | 0d |
